# Commercial Construction

Schedule from MS Project, 2016-08-22 to 2017-05-05.

## Calendars

- Standard: Mon-Fri 08:00-12:00, 13:00-17:00; Sat-Sun off. Exceptions (off unless hours are given): 2016-12-24 to 2016-12-27 (Christmas), 2017-01-01 to 2017-01-02 (New Year), 2017-05-01 (International Workers' Day).
- End of Week: Mon-Thu off; Fri 08:00-12:00, 13:00-17:00; Sat-Sun off. Exceptions (off unless hours are given): 2016-12-24 to 2016-12-27 (Christmas), 2017-01-01 to 2017-01-02 (New Year), 2017-05-01 (International Workers' Day).

## Resources

| Resource | Unit |
| --- | --- |
| G.C. General Management |  |
| Elevator Contractor Management |  |
| Plumbing Contractor Management |  |
| Electric Contractor Management |  |
| Roofing Contractor Management |  |
| G.C. Project Management |  |
| Steel Erection Contractor Management |  |
| Concrete | ton |
| Painting Material | liter |
| HVAC Contractor Management |  |
| Electric Contractor |  |
| Plumbing Contractor |  |
| G.C. Survey Crew |  |
| Site Grading Contractor |  |
| G.C. Rough Carpenter Crew |  |
| G.C. Concrete Crew |  |
| G.C. Labor Crew |  |
| Elevator Contractor |  |
| G.C. Finish Carpenter Crew |  |
| HVAC Contractor |  |
| Drywall Contractor |  |
| Painting Contractor |  |
| Carpet Contractor |  |
| Landscape Contractor |  |
| Tile Contractor |  |
| G.C. Superintendent |  |
| G.C Scheduler |  |
| G.C Procurement |  |
| Steel Erection Contractor |  |
| Paving Contractor |  |
| G.C Accounting |  |

## Schedule

| ID | WBS | Task | Type | Duration | Start | Finish | Predecessors | Total slack | Free slack | Calendar |
| --- | --- | --- | --- | --- | --- | --- | --- | --- | --- | --- |
| 1 | 1 | **General Conditions** |  | 24.75d | 2016-08-22 | 2016-09-23 |  | 32.12d | 0d |  |
| 2 | 1.1 | Receive notice to proceed and sign contract |  | 3d | 2016-08-22 | 2016-08-24 |  | 149.88d | 0d |  |
| 3 | 1.2 | Submit bond and insurance documents |  | 2d | 2016-08-25 | 2016-08-26 | 2 | 149.88d | 0d |  |
| 4 | 1.3 | Prepare and submit project schedule |  | 2d | 2016-08-29 | 2016-08-30 | 3 | 149.88d | 0d |  |
| 5 | 1.4 | Obtain building permits |  | 4d | 2016-08-31 | 2016-09-05 | 4 | 149.88d | 0d |  |
| 6 | 1.5 | Submit preliminary shop drawings |  | 2w | 2016-09-06 | 2016-09-19 | 5 | 149.88d | 0d |  |
| 7 | 1.6 | Submit monthly requests for payment |  | 6h | 2016-09-23 | 2016-09-23 | 6 | 32.12d | 0d | End of Week |
| 8 | 1.7 | Final General Condition | milestone | 0d | 2016-09-23 | 2016-09-23 | 7 | 156.12d | 0d |  |
| 9 | 2 | **Long Lead Procurement** |  | 26.25d | 2016-09-09 | 2016-10-17 |  | 106.12d | 0d |  |
| 10 | 2.1 | Submit shop drawings and order long lead items - steel |  | 2w | 2016-09-09 | 2016-09-23 | 7FF | 106.12d | 0d |  |
| 11 | 2.2 | Submit shop drawings and order long lead items - roofing |  | 2w | 2016-09-20 | 2016-10-03 | 6 | 149.88d | 0d |  |
| 12 | 2.3 | Detail, fabricate and deliver steel |  | 4w | 2016-09-20 | 2016-10-17 | 11SS | 139.88d | 0d |  |
| 13 | 2.4 | Long Lead Procurement check all items | milestone | 0d | 2016-10-17 | 2016-10-17 | 12 | 139.88d | 0d |  |
| 14 | 2 | **Mobilize on Site** |  | 7.5d | 2016-09-23 | 2016-10-05 |  | 106.12d | 0d |  |
| 15 | 2.1 | Install temporary power |  | 2.5d | 2016-09-23 | 2016-09-28 | 10 | 106.12d | 0d |  |
| 16 | 2.2 | Set up site office |  | 3d | 2016-09-28 | 2016-10-03 | 15 | 106.12d | 0d |  |
| 17 | 2.3 | Prepare site - lay down yard and temporary fencing |  | 2d | 2016-10-03 | 2016-10-05 | 16 | 106.12d | 0d |  |
| 18 | 2.4 | Finish temporay utilities | milestone | 0d | 2016-10-05 | 2016-10-05 | 17 | 148.62d | 0d |  |
| 19 | 3 | **Site Grading and Utilities** |  | 28d | 2016-10-05 | 2016-11-14 |  | 106.12d | 0d |  |
| 20 | 3.1 | Clear and grub site |  | 3d | 2016-10-05 | 2016-10-10 | 16, 17 | 106.12d | 0d |  |
| 21 | 3.2 | Rough grade site (cut and fill) |  | 1w | 2016-10-10 | 2016-10-17 | 17, 20 | 106.12d | 0d |  |
| 22 | 3.3 | Install exterior fire line and building fire riser |  | 2w | 2016-10-17 | 2016-10-31 | 21 | 106.12d | 0d |  |
| 23 | 3.4 | Perform final site grading |  | 2w | 2016-10-31 | 2016-11-14 | 22 | 106.12d | 0d |  |
| 24 | 3.5 | Install Utilities check | milestone | 0d | 2016-11-14 | 2016-11-14 | 23 | 106.12d | 0d |  |

| ID | WBS | Task | Type | Duration | Start | Finish | Predecessors | Total slack | Free slack | Constraint | Deadline |
| --- | --- | --- | --- | --- | --- | --- | --- | --- | --- | --- | --- |
| 25 | 4 | **Team meeting and discussion with partners** |  | 20.25d | 2017-01-04 | 2017-02-01 |  | 66.62d | 0d |  |  |
| 26 | 4.1 | Team meeting and discussion with partners 1 |  | 2h | 2017-01-04 | 2017-01-04 |  | 86.62d | 0d | start no earlier than 2017-01-04 |  |
| 27 | 4.2 | Team meeting and discussion with partners 2 |  | 2h | 2017-01-18 | 2017-01-18 |  | 76.62d | 0d | start no earlier than 2017-01-18 |  |
| 28 | 4.3 | Team meeting and discussion with partners 3 |  | 2h | 2017-02-01 | 2017-02-01 |  | 66.62d | 0d | start no earlier than 2017-02-01 |  |
| 29 | 5 | **Foundations** |  | 19.5d | 2016-11-14 | 2016-12-09 |  | 101.12d | 0d |  |  |
| 30 | 5.1 | Excavate foundations |  | 2w | 2016-11-14 | 2016-11-28 | 24 | 106.12d | 0d |  | 2016-12-20 |
| 31 | 5.2 | Rough-in electric and plumbing in elevator |  | 4d | 2016-11-14 | 2016-11-18 | 30SS | 110.12d | 0d |  |  |
| 32 | 5.3 | Pour column piers and foundations |  | 5d | 2016-11-18 | 2016-11-25 | 31 | 110.12d | 0d |  | 2016-11-14 |
| 33 | 5.4 | Pour concrete elevator walls |  | 1.5d | 2016-11-25 | 2016-11-28 | 31, 32 | 110.12d | 0d |  |  |
| 34 | 5.5 | Cure elevator wall concrete |  | 1d | 2016-11-28 | 2016-11-29 | 30, 33FF | 106.12d | 0d |  |  |
| 35 | 6.4 | Strip wall forms |  | 2d | 2016-12-06 | 2016-12-08 | 34FS+5d | 101.12d | 0d |  |  |
| 36 | 5.6 | Prepare and pour concrete floor in elevator pit |  | 12h | 2016-12-08 | 2016-12-09 | 35 | 101.12d | 0d |  |  |
| 37 | 5.7 | Foundation inspection | milestone | 0d | 2016-12-09 | 2016-12-09 | 36 | 101.12d | 0d |  |  |
| 38 | 6 | **Building Finishes** |  | 92d | 2016-12-09 | 2017-04-21 |  | 0d |  |  |  |
| 39 | 6.1 | Install millwork and wood trim |  | 3w | 2016-12-09 | 2017-01-04 | 37SS | 0.5d | 0d |  |  |
| 40 | 6.2 | Paint walls and woodwork |  | 1mo | 2017-01-04 | 2017-02-01 | 39 | 0.5d | 0d |  |  |
| 41 | 6.3 | Install conduit at ceiling plenum space |  | 2.5w | 2017-02-01 | 2017-02-20 | 40 | 0.5d | 0d |  |  |
| 42 | 6.5 | Install duct in ceiling plenum space |  | 3w | 2017-02-17 | 2017-03-10 | 41FS-4h | 0d |  |  |  |
| 43 | 6.6 | Install ceiling grid |  | 2w | 2017-03-10 | 2017-03-24 | 42 | 0d |  |  |  |
| 44 | 6.7 | Install ceiling tile |  | 2w | 2017-03-24 | 2017-04-07 | 43 | 0d |  |  |  |
| 45 | 6.8 | Hang wallpaper |  | 2w | 2017-04-07 | 2017-04-21 | 44 | 0d |  |  |  |
| 46 | 6.9 | Building Finishes inspection | milestone | 0d | 2017-04-21 | 2017-04-21 | 45 | 0d |  |  |  |
| 47 | 7 | **Final Clean-up and Occupancy** |  | 7d | 2017-04-21 | 2017-05-03 |  | 0d |  |  |  |
| 48 | 7.1 | Install hard tile flooring in common areas |  | 1w | 2017-04-21 | 2017-04-28 | 46 | 0d |  |  |  |
| 49 | 7.2 | Remove debris from building and do final clean-up |  | 1d | 2017-04-28 | 2017-05-02 | 48 | 0d |  |  |  |
| 50 | 7.3 | Substantial completion date |  | 1d | 2017-05-02 | 2017-05-03 | 49 | 2.12d | 0d |  |  |

| ID | WBS | Task | Duration | Start | Finish | Predecessors | Total slack | Free slack | Constraint |
| --- | --- | --- | --- | --- | --- | --- | --- | --- | --- |
| 51 | 8 | **Complete Final Inspections** | 1.31d | 2017-05-02 | 2017-05-04 |  | 0d |  |  |
| 52 | 8.1 | Complete elevator inspection and certification | 0.5d | 2017-05-02 | 2017-05-03 | 49 | 0d |  |  |
| 53 | 8.2 | Perform architect's inspection | 5h | 2017-05-03 | 2017-05-03 | 52 | 0d |  |  |
| 54 | 8.3 | Perform Fire Marshal's inspection | 90min | 2017-05-03 | 2017-05-04 | 53 | 0.81d | 0d |  |
| 55 | 9 | Issue final completion documents including warranties | 1d | 2017-05-03 | 2017-05-04 | 53 | 0d |  | start no earlier than 2017-01-09 |
| 56 | 10 | Issue final request for payment | 1d | 2017-05-04 | 2017-05-05 | 54, 55 | 0d |  |  |
